# TDIS_Schedule

Schedule from MS Project, 2015-07-06 to 2019-11-29.
CERN

## Calendars

- Standard: Mon-Fri 08:00-12:00, 13:00-17:00; Sat-Sun off. Exceptions (off unless hours are given): 2015-12-21 to 2016-01-01.

## Schedule

| ID | WBS | Task | Duration | Start | Finish | Predecessors | Total slack |
| --- | --- | --- | --- | --- | --- | --- | --- |
| 1 | 1 | Conceptual Design | 6mo | 2015-07-06 | 2015-12-18 |  | 1020d |
| 2 | 2 | Detailed design (3D) | 9mo | 2015-07-06 | 2016-03-25 |  | 0d |
| 3 | 3 | Detailed Design (2D drawings) | 3mo | 2016-03-28 | 2016-06-17 | 2 | 0d |
| 4 | 4 | Calls for tenders | 6mo | 2016-06-20 | 2016-12-02 | 3 | 0d |
| 5 | 5 | Prototyping and tests | 6mo | 2016-12-05 | 2017-05-19 | 4 | 0d |
| 6 | 6 | **Procurement and Manufacture** | 660d | 2017-02-27 | 2019-09-06 |  | 0d |
| 7 | 6.1 | Procurement | 6mo | 2017-02-27 | 2017-08-11 | 5FS-3mo | 0d |
| 8 | 6.2 | Manufacture Jaws | 12mo | 2017-08-14 | 2018-07-13 | 7 | 0d |
| 9 | 6.3 | Assembly | 6mo | 2018-07-16 | 2018-12-28 | 8 | 0d |
| 10 | 6.4 | Commissioning tests | 6mo | 2018-12-31 | 2019-06-14 | 9 | 0d |
| 11 | 6.5 | Bake-out | 3mo | 2019-06-17 | 2019-09-06 | 10 | 0d |
| 12 | 7 | Installation | 3mo | 2019-09-09 | 2019-11-29 | 11 | 0d |
